# PCServis

Schedule from MS Project, 2012-11-15 to 2012-12-20, A marks actual dates.

## Calendars

- Standard: Mon-Fri 08:00-12:00, 13:00-17:00; Sat-Sun off.

## Resources

| Resource |
| --- |
| Ondřej Polák |
| Ladislav Šťástka |

## Schedule

| ID | WBS | Task | Type | Duration | Start | Finish | Predecessors | Complete | Remaining | Total slack | Free slack | Constraint | Deadline | Resources | Work | Actual work |
| --- | --- | --- | --- | --- | --- | --- | --- | --- | --- | --- | --- | --- | --- | --- | --- | --- |
| 1 | 1 | **Startup** |  | 26d? | 2012-11-15 A | 2012-12-20 |  | 81% | 4.9d? | 0d |  |  |  |  | 308h | 236h |
| 2 | 1.1 | **Tvorba hypotézy** |  | 5d | 2012-11-15 A | 2012-11-21 A |  | 100% |  |  |  |  |  |  | 72h | 72h |
| 3 | 1.1.1 | Minimální životaschopný produkt |  | 2d | 2012-11-15 A | 2012-11-16 A |  | 100% |  |  |  |  |  | Ondřej Polák; Ladislav Šťástka | 32h | 32h |
| 4 | 1.1.2 | Určení konkurentů |  | 1d | 2012-11-19 A | 2012-11-19 A | 3 | 100% |  |  |  |  |  | Ondřej Polák [50%]; Ladislav Šťástka [50%] | 8h | 8h |
| 5 | 1.1.3 | Výpočet trhu a určení typu |  | 2d | 2012-11-19 A | 2012-11-20 A | 3 | 100% |  |  |  |  |  | Ondřej Polák [50%]; Ladislav Šťástka [50%] | 16h | 16h |
| 6 | 1.1.4 | Týdenní aktualizace |  | 1d | 2012-11-21 A | 2012-11-21 A | 5, 4 | 100% |  |  |  |  |  | Ladislav Šťástka; Ondřej Polák | 16h | 16h |
| 7 | 1.2 | **Návrh prodeje** |  | 6d | 2012-11-22 A | 2012-11-29 A |  | 100% |  |  |  |  |  |  | 72h | 72h |
| 8 | 1.2.1 | Návrh textu |  | 1d | 2012-11-22 A | 2012-11-22 A | 6 | 100% |  |  |  |  |  | Ondřej Polák; Ladislav Šťástka [50%] | 12h | 12h |
| 9 | 1.2.2 | Testování textu |  | 3d | 2012-11-23 A | 2012-11-27 A | 8 | 100% |  |  |  |  |  | Ladislav Šťástka [50%]; Ondřej Polák | 36h | 36h |
| 10 | 1.2.3 | Opakování návrhu textu |  | 2d | 2012-11-28 A | 2012-11-29 A | 9 | 100% |  |  |  |  |  | Ondřej Polák; Ladislav Šťástka [50%] | 24h | 24h |
| 11 | 1.3 | **Logistika webové stránky** |  | 4.67d | 2012-11-21 A | 2012-11-28 A |  | 100% |  |  |  |  |  |  | 24h | 24h |
| 12 | 1.3.1 | Získání jména |  | 2d | 2012-11-21 A | 2012-11-23 A | 6 | 100% |  |  |  |  |  | Ondřej Polák; Ladislav Šťástka [50%] | 8h | 8h |
| 13 | 1.3.2 | Využití třetích stran pro tvorbu webu |  | 2.67d | 2012-11-26 A | 2012-11-28 A | 12 | 100% |  |  |  |  |  | Ladislav Šťástka [50%]; Ondřej Polák [50%] | 16h | 16h |
| 14 | 1.4 | **Vytvoření minimálně životaschopného webu** |  | 5.5d | 2012-11-28 A | 2012-12-06 A |  | 100% |  |  |  |  |  |  | 44h | 44h |
| 15 | 1.4.1 | Návrh designu |  | 2d | 2012-11-28 A | 2012-11-30 A | 13 | 100% |  |  |  |  |  | Ondřej Polák [50%]; Ladislav Šťástka [50%] | 16h | 16h |
| 16 | 1.4.2 | Návrh funkcionalit |  | 3.5d | 2012-11-30 A | 2012-12-06 A | 15 | 100% |  |  |  |  |  | Ondřej Polák [50%]; Ladislav Šťástka [50%] | 28h | 28h |
| 17 | 1.5 | **Práce se zákazníky** |  | 10.83d? | 2012-12-06 A | 2012-12-20 |  | 21% | 8.51d? | 0d |  |  |  |  | 96h | 24h |
| 18 | 1.5.1 | Pozvání zákazníků |  | 3d | 2012-12-06 A | 2012-12-11 | 16, 10 | 50% | 1.5d | 4.83d | 0d |  |  | Ondřej Polák; Ladislav Šťástka | 48h | 24h |
| 19 | 1.5.2 | Zpětná odezva |  | 3d | 2012-12-11 | 2012-12-14 | 18 |  |  | 4.83d |  |  |  | Ondřej Polák; Ladislav Šťástka | 48h |  |
| 20 | 1.5.3 | Prezentace | milestone | 1d? | 2012-12-20 | 2012-12-20 |  |  |  | 0d |  | start no earlier than 2012-12-20 | 2012-12-20 |  |  |  |
